# SistemaInformatico1

Schedule from MS Project, 2013-10-03 to 2014-01-17, status date 2013-12-09, costs in $, A marks actual dates.

## Calendars

- Estándar: Mon-Fri 09:00-13:00, 15:00-19:00; Sat-Sun off.

## Resources

| Resource | Unit | Rate | Cost per use |
| --- | --- | --- | --- |
| Analista del Usuario |  | 11000 |  |
| Papeleria | Resma | 9000 |  |
| Analista DP |  | 13333.3 |  |
| Programador |  | 15000 |  |
| Auditora |  | 11111.1 |  |
| Asistente |  | 5000 | 10000 |

## Schedule

| ID | WBS | Task | Type | Duration | Start | Finish | Predecessors | Complete | Remaining | Baseline start | Baseline finish | Baseline duration | Total slack | Free slack | Constraint | Resources | Work | Actual work | Cost | Baseline cost | Actual cost |
| --- | --- | --- | --- | --- | --- | --- | --- | --- | --- | --- | --- | --- | --- | --- | --- | --- | --- | --- | --- | --- | --- |
| 1 | 1 | 1. Diseño del Sistema |  | 3w | 2013-10-03 09:00 A | 2013-10-25 18:00 A |  | 100% |  | 2013-10-03 09:00 | 2013-10-25 18:00 | 3w |  |  |  | Analista del Usuario; Analista DP [200%] | 405h | 405h | 5,085,000 | 5,085,000 | 5,085,000 |
| 2 | 8 | **Comité de Control** |  | 25.25d | 2013-10-31 09:00 A | 2013-12-05 11:00 A |  | 100% |  | 2013-10-31 09:00 | 2013-12-05 11:00 | 25.25d |  |  |  |  |  |  | 270,000 | 270,000 | 270,000 |
| 3 | 8.1 | Comité de Control 1 |  | 2h | 2013-10-31 09:00 A | 2013-10-31 11:00 A |  | 100% |  | 2013-10-31 09:00 | 2013-10-31 11:00 | 2h |  |  | start no earlier than 2013-10-31 08:00 | Papeleria [5 Resma] |  |  | 45,000 | 45,000 | 45,000 |
| 4 | 8.2 | Comité de Control 2 |  | 2h | 2013-11-07 09:00 A | 2013-11-07 11:00 A |  | 100% |  | 2013-11-07 09:00 | 2013-11-07 11:00 | 2h |  |  | start no earlier than 2013-11-07 08:00 | Papeleria [5 Resma] |  |  | 45,000 | 45,000 | 45,000 |
| 5 | 8.3 | Comité de Control 3 |  | 2h | 2013-11-14 09:00 A | 2013-11-14 11:00 A |  | 100% |  | 2013-11-14 09:00 | 2013-11-14 11:00 | 2h |  |  | start no earlier than 2013-11-14 08:00 | Papeleria [5 Resma] |  |  | 45,000 | 45,000 | 45,000 |
| 6 | 8.4 | Comité de Control 4 |  | 2h | 2013-11-21 09:00 A | 2013-11-21 11:00 A |  | 100% |  | 2013-11-21 09:00 | 2013-11-21 11:00 | 2h |  |  | start no earlier than 2013-11-21 08:00 | Papeleria [5 Resma] |  |  | 45,000 | 45,000 | 45,000 |
| 7 | 8.5 | Comité de Control 5 |  | 2h | 2013-11-28 09:00 A | 2013-11-28 11:00 A |  | 100% |  | 2013-11-28 09:00 | 2013-11-28 11:00 | 2h |  |  | start no earlier than 2013-11-28 08:00 | Papeleria [5 Resma] |  |  | 45,000 | 45,000 | 45,000 |
| 8 | 8.6 | Comité de Control 6 |  | 2h | 2013-12-05 09:00 A | 2013-12-05 11:00 A |  | 100% |  | 2013-12-05 09:00 | 2013-12-05 11:00 | 2h |  |  | start no earlier than 2013-12-05 08:00 | Papeleria [5 Resma] |  |  | 45,000 | 45,000 | 45,000 |
| 9 | 9 | **DESARROLLO** |  | 47.12d | 2013-10-29 08:00 A | 2014-01-02 10:00 |  | 57% | 20.22d | 2013-10-25 18:00 | 2014-01-06 13:00 | 50.62d | 0d |  |  |  | 929h | 546.5h | 15,458,666.67 | 15,583,333.12 | 8,824,166.67 |
| 10 | 9.5 | 2. Detalles y Codificación |  | 3.16w | 2013-10-29 08:00 A | 2013-11-21 17:00 A | 1 | 100% |  | 2013-10-25 18:00 | 2013-11-27 12:00 | 4w |  |  |  | Analista del Usuario; Analista DP | 344h | 344h | 4,508,666.67 | 4,633,333.44 | 4,508,666.67 |
| 11 | 9.6 | 3. Preparar prueba del Sistema |  | 3w | 2013-11-25 08:00 A | 2013-12-17 18:00 | 10 | 50% | 1.5w | 2013-11-27 12:00 | 2013-12-20 11:00 | 3w | 0d |  |  | Programador; Analista del Usuario; Auditora | 405h | 202.5h | 8,460,000 | 8,460,000 | 4,230,000 |
| 12 | 9.7 | 4. Preparar Auditoria / Control |  | 2w | 2013-12-17 18:00 | 2014-01-02 10:00 | 11 |  |  | 2013-12-20 11:00 | 2014-01-06 13:00 | 2w | 0d |  |  | Programador; Analista del Usuario | 180h |  | 2,340,000 | 2,340,000 |  |
| 13 | 9.8 | FIN DESARROLLO | milestone | 0w | 2014-01-02 10:00 | 2014-01-02 10:00 | 12 |  |  | 2014-01-06 13:00 | 2014-01-06 13:00 | 0w | 0d |  |  |  |  |  |  |  |  |
| 14 | 5 | 5. Documentación |  | 3w | 2013-10-25 18:00 A | 2013-11-19 17:00 | 1 | 90% | 0.3w | 2013-10-25 18:00 | 2013-11-19 17:00 | 3w | 24.06d | 0d |  | Analista del Usuario; Analista DP; Asistente | 405h | 378h | 4,147,777.6 | 4,147,777.6 | 3,931,777.92 |
| 15 | 6 | 6. Preparar Procedimientos y guías |  | 2w | 2013-11-19 17:00 A | 2013-12-04 19:00 | 14 | 75% | 0.5w | 2013-11-19 17:00 | 2013-12-04 19:00 | 2w | 15.62d |  |  | Asistente; Analista del Usuario; Programador | 270h | 202.5h | 2,800,000 | 2,800,000 | 2,102,500 |
| 16 | 7 | 7. Prueba del Sistema |  | 2w | 2014-01-02 10:00 | 2014-01-17 12:00 | 12, 15 |  |  | 2014-01-06 15:00 | 2014-01-21 17:00 | 2w | 0d |  |  | Programador [200%]; Analista del Usuario; Analista DP; Papeleria [1 Resma] | 360h |  | 5,032,333.33 | 5,032,333.44 |  |
